# Edwin PhD

Schedule from MS Project, 2025-12-01 to 2027-08-17, A marks actual dates.
Rochester Institute of Technology

## Calendars

- Standard: Mon-Fri 08:00-12:00, 13:00-17:00; Sat-Sun off.

## Schedule

| ID | WBS | Task | Type | Duration | Start | Finish | Predecessors | Complete | Remaining | Total slack | Free slack | Constraint |
| --- | --- | --- | --- | --- | --- | --- | --- | --- | --- | --- | --- | --- |
| 1 | 1 | **Edwin Alexani PhD Thesis Remaining Work** |  | 447d? | 2025-12-01 A | 2027-08-17 |  | 27% | 325.61d? | 0d |  |  |
| 2 | 1.1 | JATIS paper | manual | 218d | 2025-12-01 A | 2026-09-30 |  | 90% | 21.8d |  |  |  |
| 3 | 1.2 | **Requirements** |  | 447d | 2025-12-01 A | 2027-08-17 |  | 27% | 327.97d | 0d |  |  |
| 4 | 1.2.1 | form PhD committee | manual | 67d | 2026-05-01 A | 2026-08-01 A |  | 100% |  |  |  |  |
| 5 | 1.2.2 | defend PhD proposal | manual | 87d | 2025-12-01 | 2026-03-31 |  |  |  |  |  |  |
| 6 | 1.2.3 | submit request to walk the plank (graduation ceremony) for summer defense | milestone, manual | 0d | 2027-04-01 | 2027-04-01 |  |  |  |  |  |  |
| 7 | 1.2.4 | write PhD thesis |  | 19mo | 2025-12-08 A | 2027-05-21 | 10FS-22mo | 20% | 15.2mo | 62d |  |  |
| 8 | 1.2.5 | advertise PhD thesis defense | manual | 1d | 2027-05-27 | 2027-05-27 | 10FS-7w |  |  |  |  |  |
| 9 | 1.2.6 | send PhD thesis to committeee for review | manual | 1d | 2027-06-10 | 2027-06-10 | 10FS-5w |  |  |  |  |  |
| 10 | 1.2.7 | defend PhD thesis | manual | 1d | 2027-08-17 | 2027-08-17 | 5FF+18mo |  |  |  |  |  |
| 11 | 1.3 | **Can SPSCMOS satisfy HWO requirements?** |  | 393d? | 2025-12-10 A | 2027-06-11 |  | 21% | 311.3d? | 47d |  |  |
| 12 | 1.3.1 | **What is the Performance of the HWK4123?** |  | 1d? | 2025-12-10 A | 2025-12-10 |  | 37% | 0.63d? |  |  |  |
| 13 | 1.3.1.1 | review acquired data and finalize results | manual | 52w | 2025-12-10 A | 2026-12-08 |  | 80% | 10.4w |  |  |  |
| 14 | 1.3.1.2 | **How do we characterize quantum yield?** |  | 85d | 2026-08-03 A | 2026-11-27 |  | 18% | 70d | 22d |  |  |
| 15 | 1.3.1.2.1 | develop theoretical framework to characterize quantum yield | manual | 50d | 2026-08-03 A | 2026-10-09 | 4 | 30% | 35d |  |  |  |
| 16 | 1.3.1.2.2 | complete system calibration for QE testing | manual | 15d | 2026-10-12 | 2026-10-30 | 15 |  |  |  |  |  |
| 17 | 1.3.1.2.3 | acquire data for QE and QY |  | 1mo | 2026-11-02 | 2026-11-27 | 16 |  |  | 22d | 0d |  |
| 18 | 1.3.1.3 | **What causes low-signal nonlinearity?** |  | 195d | 2026-06-22 A | 2027-03-19 |  | 40% | 117d | 107d |  |  |
| 19 | 1.3.1.3.1 | aqcuire data for PTC at different temperatures and wavelengths |  | 3mo | 2026-11-18 A | 2027-02-09 | 17 | 50% | 1.5mo | 0d |  | as late as possible |
| 20 | 1.3.1.3.2 | acquire data for different TG voltage and clocking |  | 1mo | 2027-02-10 A | 2027-03-09 | 19 | 20% | 0.8mo | 0d |  |  |
| 21 | 1.3.1.3.3 | acquire data for PTC at different temperatures |  | 3w | 2026-08-31 A | 2027-02-22 | 19 | 40% | 1.8w | 126d |  |  |
| 22 | 1.3.1.3.4 | compare conversion gain for PTC and PCH |  | 2w | 2026-06-22 A | 2027-03-19 | 20 | 20% | 1.6w | 107d |  |  |
| 23 | 1.3.1.4 | **What causes the dark current plateau and glow?** |  | 207d | 2026-08-03 A | 2027-05-18 |  | 17% | 171.81d | 65d |  |  |
| 24 | 1.3.1.4.1 | examine archival data for multiplexer glow |  | 20w | 2026-08-03 A | 2026-12-18 | 4 | 50% | 10w | 172d |  |  |
| 25 | 1.3.1.4.2 | develop theoretical framework for unit cell glow | manual | 30w | 2026-08-03 A | 2027-02-26 | 4 | 10% | 27w |  |  |  |
| 26 | 1.3.1.4.3 | aquire data to test theoretical framework for unit cell glow |  | 10w | 2027-03-10 | 2027-05-18 | 20, 25 |  |  | 65d |  |  |
| 27 | 1.3.1.4.4 | identify sources of dark current plateau | manual | 40w | 2026-08-03 A | 2027-05-07 | 4 | 10% | 36w |  |  |  |

| ID | WBS | Task | Type | Duration | Start | Finish | Predecessors | Complete | Remaining | Total slack | Free slack | Constraint |
| --- | --- | --- | --- | --- | --- | --- | --- | --- | --- | --- | --- | --- |
| 28 | 1.3.2 | **Mees Observing** |  | 320d | 2026-01-01 A | 2027-03-24 |  | 11% | 284.63d | 64d |  |  |
| 29 | 1.3.2.1 | complete data reduction for prior Mees observations | manual | 14mo | 2026-01-01 A | 2027-01-27 |  | 15% | 11.9mo |  |  |  |
| 30 | 1.3.2.2 | identify good read mode for winter observing | manual | 1mo | 2026-11-02 | 2026-11-27 |  |  |  |  |  | start no earlier than 2026-11-02 |
| 31 | 1.3.2.3 | complete winter observing |  | 2mo | 2026-11-30 | 2027-01-22 | 30 |  |  | 107d | 3d |  |
| 32 | 1.3.2.4 | wrap up all Mees data | manual | 2mo | 2027-01-28 | 2027-03-24 | 31 |  |  |  |  |  |
| 33 | 1.3.3 | **Simulation Science** |  | 366d | 2026-01-16 A | 2027-06-11 |  | 6% | 344.33d | 0d |  |  |
| 34 | 1.3.3.1 | restart ExoVista to be able to make new simulations | manual | 80d | 2026-09-01 A | 2026-12-21 |  | 30% | 56d |  |  |  |
| 35 | 1.3.3.2 | estimate end-to-end throughput for HWO for all parts except detector | manual | 22d | 2026-01-16 A | 2026-02-16 A |  | 100% |  |  |  |  |
| 36 | 1.3.3.3 | add galaxy spectrum analysis simulation case | manual | 45w | 2026-08-03 | 2027-06-11 | 4 |  |  |  |  |  |
| 37 | 1.3.3.4 | **What is the impact of a roudning step using BER on SNR?** |  | 225d | 2026-08-03 | 2027-06-11 |  |  |  | 0d |  |  |
| 38 | 1.3.3.4.1 | develop theoretical framwork for using BER in SNR calculations | manual | 45w | 2026-08-03 | 2027-06-11 | 4 |  |  |  |  |  |
| 39 | 1.3.3.4.2 | simulate SNR of observations with and without rounding step | manual | 45w | 2026-08-03 | 2027-06-11 | 4 |  |  |  |  |  |
